# Constructing a new office building

Schedule from MS Project, 2012-01-09 to 2012-06-22.
Outlander Spices

## Calendars

- Outlander office construction: Mon-Fri 08:00-12:00, 13:00-17:00; Sat-Sun off. Exceptions (off unless hours are given): 2012-03-09 (Company holiday), 2012-05-25 (Company holiday), 2012-05-28 (Memorial Day).
- subcontracted tasks: Mon-Fri 08:00-12:00, 13:00-17:00; Sat-Sun off. Exceptions (off unless hours are given): 2012-05-25 (Company holiday), 2012-05-28 (Memorial Day).

## Resources

| Resource | Group |
| --- | --- |
| Kathy Sinclair | MGMT |
| David James | CONST |
| Airfare to Chicago | Travel |
| Pat Leary | ADMN |
| Curt Allen | CONST |
| Peter Jones | CONST |
| Ann Salinski | CONST |
| Susan Gianni | CONST |
| Joe Simmons | External |
| Fred Little | CONST |
| Architect | External |
| Tim Walson | CONST |
| Jerry Davis | CONST |
| Laurie Macurthy | CONST |
| Contract laborers | Contract labor |
| Backhoe | EQUIP |

## Schedule

| ID | WBS | Task | Type | Duration | Start | Finish | Predecessors | Total slack | Constraint | Calendar | Resources | Work |
| --- | --- | --- | --- | --- | --- | --- | --- | --- | --- | --- | --- | --- |
| 1 | 1 | **Review meeting** |  | 87.25d | 2012-02-03 | 2012-06-08 |  | 10.25d |  |  |  |  |
| 2 | 1.1 | Review meeting 1 |  | 2h | 2012-02-03 | 2012-02-03 |  | 98.25d | start no earlier than 2012-02-03 |  |  |  |
| 3 | 1.2 | Review meeting 2 |  | 2h | 2012-03-12 | 2012-03-12 |  | 73.25d | start no earlier than 2012-03-09 |  |  |  |
| 4 | 1.3 | Review meeting 3 |  | 2h | 2012-04-06 | 2012-04-06 |  | 53.25d | start no earlier than 2012-04-06 |  |  |  |
| 5 | 1.4 | Review meeting 4 |  | 2h | 2012-05-04 | 2012-05-04 |  | 33.25d | start no earlier than 2012-05-04 |  |  |  |
| 6 | 1.5 | Review meeting 5 |  | 2h | 2012-06-08 | 2012-06-08 |  | 8.25d | start no earlier than 2012-06-08 |  |  |  |
| 7 | 2 | **Pre-construction** |  | 41d | 2012-01-09 | 2012-03-05 |  | 0d |  |  |  | 256h |
| 8 | 2.1 | Get approvals |  | 2w | 2012-01-09 | 2012-01-20 |  | 0d |  |  | Pat Leary | 80h |
| 9 | 2.2 | Select architect |  | 3w | 2012-01-09 | 2012-01-27 | 8SS | 0d |  |  | Kathy Sinclair [20%] | 24h |
| 10 | 2.3 | Draw plans |  | 3w | 2012-01-30 | 2012-02-17 | 9, 8 | 0d |  |  | Architect | 120h |
| 11 | 2.4 | Review blueprints |  | 4d | 2012-02-20 | 2012-02-23 | 10 | 0d |  |  | Architect | 32h |
| 12 | 2.5 | Order materials |  | 7d | 2012-02-24 | 2012-03-05 | 11 | 0d |  |  |  |  |
| 13 | 2.6 | Building permit | milestone | 0d | 2012-03-05 | 2012-03-05 | 12 | 0d |  |  |  |  |
| 14 | 3 | **Foundation** |  | 22d | 2012-03-06 | 2012-04-05 |  | 0d |  |  |  | 24h |
| 15 | 3.1 | Survey and stake |  | 2d | 2012-03-06 | 2012-03-07 | 13 | 0d |  |  |  |  |
| 16 | 3.2 | Excavate for foundation |  | 3d | 2012-03-08 | 2012-03-12 | 15 | 0d |  | subcontracted tasks | Backhoe [0.1%]; Joe Simmons | 24h |
| 17 | 3.3 | Footings |  | 3d | 2012-03-13 | 2012-03-15 | 16 | 0d |  |  |  |  |
| 18 | 3.4 | Install drainage |  | 3d | 2012-03-16 | 2012-03-20 | 17 | 0d |  |  |  |  |
| 19 | 3.5 | Install external utilities |  | 4d | 2012-03-21 | 2012-03-26 | 18 | 0d |  |  |  |  |
| 20 | 3.6 | Foundation walls |  | 4d | 2012-03-27 | 2012-03-30 | 19 | 0d |  |  |  |  |
| 21 | 3.7 | Lay slab foundation |  | 2d | 2012-04-02 | 2012-04-03 | 20 | 0d |  |  |  |  |
| 22 | 3.8 | Backfill |  | 2d | 2012-04-04 | 2012-04-05 | 21 | 0d |  |  |  |  |
| 23 | 4 | **External work** |  | 17d | 2012-04-06 | 2012-04-30 |  | 0d |  |  |  |  |
| 24 | 4.1 | Erect steel frame |  | 4d | 2012-04-06 | 2012-04-11 | 22 | 0d |  |  |  |  |
| 25 | 4.2 | Erect external walls |  | 6d | 2012-04-12 | 2012-04-19 | 24 | 0d |  |  |  |  |
| 26 | 4.3 | Install windows, external doors |  | 4d | 2012-04-20 | 2012-04-25 | 25 | 0d |  |  |  |  |
| 27 | 4.4 | Install siding |  | 3d | 2012-04-26 | 2012-04-30 | 26 | 36.5d |  |  |  |  |
| 28 | 4.5 | Install roof |  | 4d | 2012-04-20 | 2012-04-25 | 25 | 0d |  |  |  |  |

| ID | WBS | Task | Type | Duration | Start | Finish | Predecessors | Total slack | Constraint |
| --- | --- | --- | --- | --- | --- | --- | --- | --- | --- |
| 29 | 5 | **Internal work** |  | 39.5d | 2012-04-26 | 2012-06-22 |  | 0d |  |
| 30 | 5.1 | Frame internal walls |  | 4d | 2012-04-26 | 2012-05-01 | 28, 26 | 0d |  |
| 31 | 5.2 | **Distribute utilities** |  | 8d | 2012-05-02 | 2012-05-11 |  | 0d |  |
| 32 | 5.2.1 | Distribute heating, cooling |  | 6d | 2012-05-02 | 2012-05-09 | 30 | 2d |  |
| 33 | 5.2.2 | Distribute electricity, phone, cabling |  | 8d | 2012-05-02 | 2012-05-11 | 30 | 0d |  |
| 34 | 5.2.3 | Distribute water, sewer |  | 3d | 2012-05-02 | 2012-05-04 | 30 | 5d |  |
| 35 | 5.3 | Insulation |  | 2d | 2012-05-14 | 2012-05-15 | 34, 33, 32 | 0d |  |
| 36 | 5.4 | Install & finish drywall |  | 4d | 2012-05-16 | 2012-05-21 | 35 | 0d |  |
| 37 | 5.5 | Paint |  | 2d | 2012-05-22 | 2012-05-23 | 36 | 0d |  |
| 38 | 5.6 | Install flooring |  | 2d | 2012-05-29 | 2012-05-30 | 37FS+1d | 0d |  |
| 39 | 5.7 | Install trim |  | 6d | 2012-05-31 | 2012-06-07 | 38 | 0d |  |
| 40 | 5.8 | Install built-in amenities |  | 6d | 2012-06-08 | 2012-06-15 | 39 | 0d |  |
| 41 | 5.9 | Install furnishings |  | 4d | 2012-06-14 | 2012-06-20 | 40FS-2.5% | 0d |  |
| 42 | 5.10 | Certificate of Occupancy |  | 2d | 2012-06-20 | 2012-06-22 | 41 | 0d |  |
| 43 | 6 | Office building complete | milestone | 0d | 2012-06-22 | 2012-06-22 | 42, 27 | 0d | finish no later than 2012-07-02 |
