# Build a new office

Schedule from MS Project, 2011-01-10 to 2011-06-22, costs in $.
Outlander Spices

## Calendars

- Outlander Spices Construction: Mon-Fri 08:00-12:00, 13:00-17:00; Sat-Sun off.
- Subcontracted tasks: Mon-Fri 08:00-12:00, 13:00-17:00; Sat-Sun off.

## Resources

| Resource | Group | Unit | Rate |
| --- | --- | --- | --- |
| Kathy Sinclair | Project mgmt. |  | 30 |
| Pat Leary | Admin. Assistant |  | 15 |
| David James | Labor |  | 15 |
| Paint | Purchased | gallon | 30 |
| Metal stud | Purchased | each | 3 |
| Curt Allen | Labor |  | 15 |
| Peter Jones | Skilled labor |  | 30 |
| Ann Salinski | Labor |  | 15 |
| Susan Gianni | Skilled labor |  | 30 |
| Joe Simmons | External |  | 24 |
| Fred Little | Skilled labor |  | 30 |
| Architect | External |  |  |
| Tim Walson | Labor |  | 15 |
| Jerry Davis | Labor |  | 15 |
| Laurie Macurthy | Labor |  | 15 |
| Contract laborers | Contract labor |  | 15 |
| Backhoe | Hired equipment |  | 62.5 |

## Schedule

| ID | WBS | Task | Type | Duration | Start | Finish | Predecessors | Total slack | Constraint | Calendar | Resources | Work | Cost |
| --- | --- | --- | --- | --- | --- | --- | --- | --- | --- | --- | --- | --- | --- |
| 1 | 1 | **Review meeting** |  | 90.25d | 2011-02-04 | 2011-06-10 |  | 8.25d |  |  |  | 30h | 600 |
| 2 | 1.1 | Review meeting 1 |  | 2h | 2011-02-04 | 2011-02-04 |  | 98.25d | start no earlier than 2011-02-04 |  | Kathy Sinclair; David James; Pat Leary | 6h | 120 |
| 3 | 1.2 | Review meeting 2 |  | 2h | 2011-03-11 | 2011-03-11 |  | 73.25d | start no earlier than 2011-03-11 |  | Kathy Sinclair; David James; Pat Leary | 6h | 120 |
| 4 | 1.3 | Review meeting 3 |  | 2h | 2011-04-08 | 2011-04-08 |  | 53.25d | start no earlier than 2011-04-08 |  | Kathy Sinclair; David James; Pat Leary | 6h | 120 |
| 5 | 1.4 | Review meeting 4 |  | 2h | 2011-05-06 | 2011-05-06 |  | 33.25d | start no earlier than 2011-05-06 |  | Kathy Sinclair; David James; Pat Leary | 6h | 120 |
| 6 | 1.5 | Review meeting 5 |  | 2h | 2011-06-10 | 2011-06-10 |  | 8.25d | start no earlier than 2011-06-10 |  | Kathy Sinclair; David James; Pat Leary | 6h | 120 |
| 7 | 2 | **Pre-construction** |  | 41d | 2011-01-10 | 2011-03-07 |  | 0d |  |  |  | 344h | 63,720 |
| 8 | 2.1 | Get approvals |  | 2w | 2011-01-10 | 2011-01-21 |  | 0d |  |  | Pat Leary | 80h | 1,200 |
| 9 | 2.2 | Select architect |  | 3w | 2011-01-10 | 2011-01-28 | 8SS | 0d |  |  | Kathy Sinclair [20%] | 24h | 720 |
| 10 | 2.3 | Draw plans |  | 3w | 2011-01-31 | 2011-02-18 | 9, 8 | 0d |  |  | Architect | 120h | 60,000 |
| 11 | 2.4 | Review blueprints |  | 4d | 2011-02-21 | 2011-02-24 | 10 | 0d |  |  | Architect; Kathy Sinclair | 64h | 960 |
| 12 | 2.5 | Order materials |  | 7d | 2011-02-25 | 2011-03-07 | 11 | 0d |  |  | Pat Leary | 56h | 840 |
| 13 | 2.6 | Building permit | milestone | 0d | 2011-03-07 | 2011-03-07 | 12 | 0d |  |  |  |  |  |
| 14 | 3 | **Foundation** |  | 23d | 2011-03-08 | 2011-04-07 |  | 0d |  |  |  | 248h | 6,876 |
| 15 | 3.1 | Survey and stake |  | 2d | 2011-03-08 | 2011-03-09 | 13 | 0d |  |  |  |  |  |
| 16 | 3.2 | Excavate for foundation |  | 3d | 2011-03-10 | 2011-03-14 | 15 | 0d |  | Subcontracted tasks | Backhoe; Joe Simmons | 48h | 2,076 |
| 17 | 3.3 | Footings |  | 3d | 2011-03-15 | 2011-03-17 | 16 | 0d |  |  |  |  |  |
| 18 | 3.4 | Install drainage |  | 3d | 2011-03-18 | 2011-03-22 | 17 | 0d |  |  | Joe Simmons | 24h | 576 |
| 19 | 3.5 | Install external utilities |  | 4d | 2011-03-23 | 2011-03-28 | 18 | 0d |  |  | Peter Jones; Susan Gianni; Fred Little; Ann Salinski; Curt Allen | 160h | 3,840 |
| 20 | 3.6 | Foundation walls |  | 4d | 2011-03-29 | 2011-04-01 | 19 | 0d |  |  |  |  |  |
| 21 | 3.7 | Lay slab foundation |  | 2d | 2011-04-04 | 2011-04-05 | 20 | 0d |  |  | Joe Simmons | 16h | 384 |
| 22 | 3.8 | Backfill |  | 2d | 2011-04-06 | 2011-04-07 | 21 | 0d |  |  |  |  |  |
| 23 | 4 | **External work** |  | 17d | 2011-04-08 | 2011-05-02 |  | 0d |  |  |  | 776h | 11,640 |
| 24 | 4.1 | Erect steel frame |  | 4d | 2011-04-08 | 2011-04-13 | 22 | 0d |  |  | David James; Jerry Davis; Laurie Macurthy | 96h | 1,440 |
| 25 | 4.2 | Erect external walls |  | 6d | 2011-04-14 | 2011-04-21 | 24 | 0d |  |  | David James; Ann Salinski; Curt Allen; Jerry Davis; Laurie Macurthy; Tim Walson | 288h | 4,320 |
| 26 | 4.3 | Install windows, external doors |  | 4d | 2011-04-22 | 2011-04-27 | 25 | 0d |  |  | David James; Laurie Macurthy; Tim Walson; Contract laborers [200%] | 160h | 2,400 |
| 27 | 4.4 | Install siding |  | 3d | 2011-04-28 | 2011-05-02 | 26 | 36.5d |  |  | Ann Salinski; Curt Allen; Jerry Davis | 72h | 1,080 |
| 28 | 4.5 | Install roof |  | 4d | 2011-04-22 | 2011-04-27 | 25 | 0d |  |  | Ann Salinski; Curt Allen; Jerry Davis; Contract laborers [200%] | 160h | 2,400 |

| ID | WBS | Task | Type | Duration | Start | Finish | Predecessors | Total slack | Constraint | Resources | Work | Cost |
| --- | --- | --- | --- | --- | --- | --- | --- | --- | --- | --- | --- | --- |
| 29 | 5 | **Internal work** |  | 39.5d | 2011-04-28 | 2011-06-22 |  | 0d |  |  | 1260h | 22,620 |
| 30 | 5.1 | Frame internal walls |  | 4d | 2011-04-28 | 2011-05-03 | 28, 26 | 0d |  | David James; Laurie Macurthy; Tim Walson | 96h | 1,440 |
| 31 | 5.2 | **Distribute utilities** |  | 8d | 2011-05-04 | 2011-05-13 |  | 0d |  |  | 484h | 9,480 |
| 32 | 5.2.1 | Distribute heating, cooling |  | 6d | 2011-05-04 | 2011-05-11 | 30 | 2d |  | Fred Little; Curt Allen; David James; Peter Jones [50%] | 168h | 3,600 |
| 33 | 5.2.2 | Distribute electricity, phone, cabling |  | 8d | 2011-05-04 | 2011-05-13 | 30 | 0d |  | David James; Jerry Davis; Ann Salinski; Susan Gianni | 256h | 4,800 |
| 34 | 5.2.3 | Distribute water, sewer |  | 3d | 2011-05-04 | 2011-05-06 | 30 | 5d |  | Laurie Macurthy; Tim Walson; Peter Jones [50%] | 60h | 1,080 |
| 35 | 5.3 | Insulation |  | 2d | 2011-05-16 | 2011-05-17 | 34, 33, 32 | 0d |  |  |  |  |
| 36 | 5.4 | Install & finish drywall |  | 4d | 2011-05-18 | 2011-05-23 | 35 | 0d |  | David James; Laurie Macurthy; Tim Walson | 96h | 1,440 |
| 37 | 5.5 | Paint |  | 2d | 2011-05-24 | 2011-05-25 | 36 | 0d |  | David James; Ann Salinski; Curt Allen | 48h | 720 |
| 38 | 5.6 | Install flooring |  | 2d | 2011-05-27 | 2011-05-30 | 37FS+1d | 0d |  | David James; Ann Salinski; Jerry Davis | 48h | 720 |
| 39 | 5.7 | Install trim |  | 6d | 2011-05-31 | 2011-06-07 | 38 | 0d |  | David James; Ann Salinski; Laurie Macurthy | 144h | 2,160 |
| 40 | 5.8 | Install built-in amenities |  | 6d | 2011-06-08 | 2011-06-15 | 39 | 0d |  | Susan Gianni; Peter Jones; Ann Salinski; Curt Allen; Jerry Davis | 240h | 5,040 |
| 41 | 5.9 | Install furnishings |  | 4d | 2011-06-14 | 2011-06-20 | 40FS-2.5% | 0d |  | Laurie Macurthy; Tim Walson; David James | 96h | 1,440 |
| 42 | 5.10 | Certificate of Occupancy |  | 2d | 2011-06-20 | 2011-06-22 | 41 | 0d |  | Kathy Sinclair [25%]; Pat Leary [25%] | 8h | 180 |
| 43 | 6 | Office building complete | milestone | 0d | 2011-06-22 | 2011-06-22 | 42, 27 | 0d | finish no later than 2011-07-04 |  |  |  |
