# Constructing a new office building

Schedule from MS Project, 2009-02-02 to 2011-06-22, costs in $.
Outlander Spices

## Calendars

- Outlander Spices Construction: Mon-Fri 08:00-12:00, 13:00-17:00; Sat-Sun off.
- Subcontracted tasks: Mon-Fri 08:00-12:00, 13:00-17:00; Sat-Sun off.

## Resources

| Resource | Group | Unit | Rate |
| --- | --- | --- | --- |
| Kathy Sinclair | Project mgmt. |  | 30 |
| Pat Leary | Admin. Assistant |  | 15 |
| David James | Labor |  | 15 |
| Paint | Purchased | gallon | 30 |
| Metal stud | Purchased | each | 3 |
| Curt Allen | Labor |  | 15 |
| Peter Jones | Skilled labor |  | 30 |
| Ann Salinski | Labor |  | 15 |
| Susan Gianni | Skilled labor |  | 30 |
| Joe Simmons | External |  | 24 |
| Fred Little | Skilled labor |  | 30 |
| Architect | External |  |  |
| Tim Walson | Labor |  | 15 |
| Jerry Davis | Labor |  | 15 |
| Laurie Macurthy | Labor |  | 15 |
| Contract laborers | Contract labor |  | 15 |
| Backhoe | Hired equipment |  | 62.5 |

## Schedule

| ID | WBS | Task | Type | Duration | Start | Finish | Predecessors | Total slack | Constraint | Resources | Work | Cost |
| --- | --- | --- | --- | --- | --- | --- | --- | --- | --- | --- | --- | --- |
| 1 | 1 | **Weekly status** |  | 105.12d | 2009-02-02 08:00 | 2009-06-29 09:00 |  | 517.38d |  |  |  |  |
| 2 | 1.1 | Weekly status 1 |  | 1h | 2009-02-02 08:00 | 2009-02-02 09:00 |  | 622.38d | start no earlier than 2009-02-02 08:00 |  |  |  |
| 3 | 1.2 | Weekly status 2 |  | 1h | 2009-02-09 08:00 | 2009-02-09 09:00 |  | 617.38d | start no earlier than 2009-02-09 08:00 |  |  |  |
| 4 | 1.3 | Weekly status 3 |  | 1h | 2009-02-16 08:00 | 2009-02-16 09:00 |  | 612.38d | start no earlier than 2009-02-16 08:00 |  |  |  |
| 5 | 1.4 | Weekly status 4 |  | 1h | 2009-02-23 08:00 | 2009-02-23 09:00 |  | 607.38d | start no earlier than 2009-02-23 08:00 |  |  |  |
| 6 | 1.5 | Weekly status 5 |  | 1h | 2009-03-02 08:00 | 2009-03-02 09:00 |  | 602.38d | start no earlier than 2009-03-02 08:00 |  |  |  |
| 7 | 1.6 | Weekly status 6 |  | 1h | 2009-03-09 08:00 | 2009-03-09 09:00 |  | 597.38d | start no earlier than 2009-03-09 08:00 |  |  |  |
| 8 | 1.7 | Weekly status 7 |  | 1h | 2009-03-16 08:00 | 2009-03-16 09:00 |  | 592.38d | start no earlier than 2009-03-16 08:00 |  |  |  |
| 9 | 1.8 | Weekly status 8 |  | 1h | 2009-03-23 08:00 | 2009-03-23 09:00 |  | 587.38d | start no earlier than 2009-03-23 08:00 |  |  |  |
| 10 | 1.9 | Weekly status 9 |  | 1h | 2009-03-30 08:00 | 2009-03-30 09:00 |  | 582.38d | start no earlier than 2009-03-30 08:00 |  |  |  |
| 11 | 1.10 | Weekly status 10 |  | 1h | 2009-04-06 08:00 | 2009-04-06 09:00 |  | 577.38d | start no earlier than 2009-04-06 08:00 |  |  |  |
| 12 | 1.11 | Weekly status 11 |  | 1h | 2009-04-13 08:00 | 2009-04-13 09:00 |  | 572.38d | start no earlier than 2009-04-13 08:00 |  |  |  |
| 13 | 1.12 | Weekly status 12 |  | 1h | 2009-04-20 08:00 | 2009-04-20 09:00 |  | 567.38d | start no earlier than 2009-04-20 08:00 |  |  |  |
| 14 | 1.13 | Weekly status 13 |  | 1h | 2009-04-27 08:00 | 2009-04-27 09:00 |  | 562.38d | start no earlier than 2009-04-27 08:00 |  |  |  |
| 15 | 1.14 | Weekly status 14 |  | 1h | 2009-05-04 08:00 | 2009-05-04 09:00 |  | 557.38d | start no earlier than 2009-05-04 08:00 |  |  |  |
| 16 | 1.15 | Weekly status 15 |  | 1h | 2009-05-11 08:00 | 2009-05-11 09:00 |  | 552.38d | start no earlier than 2009-05-11 08:00 |  |  |  |
| 17 | 1.16 | Weekly status 16 |  | 1h | 2009-05-18 08:00 | 2009-05-18 09:00 |  | 547.38d | start no earlier than 2009-05-18 08:00 |  |  |  |
| 18 | 1.17 | Weekly status 17 |  | 1h | 2009-05-25 08:00 | 2009-05-25 09:00 |  | 542.38d | start no earlier than 2009-05-25 08:00 |  |  |  |
| 19 | 1.18 | Weekly status 18 |  | 1h | 2009-06-01 08:00 | 2009-06-01 09:00 |  | 537.38d | start no earlier than 2009-06-01 08:00 |  |  |  |
| 20 | 1.19 | Weekly status 19 |  | 1h | 2009-06-08 08:00 | 2009-06-08 09:00 |  | 532.38d | start no earlier than 2009-06-08 08:00 |  |  |  |
| 21 | 1.20 | Weekly status 20 |  | 1h | 2009-06-15 08:00 | 2009-06-15 09:00 |  | 527.38d | start no earlier than 2009-06-15 08:00 |  |  |  |
| 22 | 1.21 | Weekly status 21 |  | 1h | 2009-06-22 08:00 | 2009-06-22 09:00 |  | 522.38d | start no earlier than 2009-06-22 08:00 |  |  |  |
| 23 | 1.22 | Weekly status 22 |  | 1h | 2009-06-29 08:00 | 2009-06-29 09:00 |  | 517.38d | start no earlier than 2009-06-29 08:00 |  |  |  |
| 24 | 2 | **Pre-construction** |  | 41d | 2011-01-10 08:00 | 2011-03-07 17:00 |  | 0d |  |  | 344h | 63,720 |
| 25 | 2.1 | Get approvals |  | 2w | 2011-01-10 08:00 | 2011-01-21 17:00 |  | 0d |  | Pat Leary | 80h | 1,200 |
| 26 | 2.2 | Select architect |  | 3w | 2011-01-10 08:00 | 2011-01-28 17:00 | 25SS | 0d |  | Kathy Sinclair [20%] | 24h | 720 |
| 27 | 2.3 | Draw plans |  | 3w | 2011-01-31 08:00 | 2011-02-18 17:00 | 26, 25 | 0d |  | Architect | 120h | 60,000 |
| 28 | 2.4 | Review blueprints |  | 4d | 2011-02-21 08:00 | 2011-02-24 17:00 | 27 | 0d |  | Architect; Kathy Sinclair | 64h | 960 |
| 29 | 2.5 | Order materials |  | 7d | 2011-02-25 08:00 | 2011-03-07 17:00 | 28 | 0d |  | Pat Leary | 56h | 840 |
| 30 | 2.6 | Building permit | milestone | 0d | 2011-03-07 17:00 | 2011-03-07 17:00 | 29 | 0d |  |  |  |  |

| ID | WBS | Task | Type | Duration | Start | Finish | Predecessors | Total slack | Constraint | Calendar | Resources | Work | Cost |
| --- | --- | --- | --- | --- | --- | --- | --- | --- | --- | --- | --- | --- | --- |
| 31 | 3 | **Foundation** |  | 23d | 2011-03-08 08:00 | 2011-04-07 17:00 |  | 0d |  |  |  | 248h | 6,876 |
| 32 | 3.1 | Survey and stake |  | 2d | 2011-03-08 08:00 | 2011-03-09 17:00 | 30 | 0d |  |  |  |  |  |
| 33 | 3.2 | Excavate for foundation |  | 3d | 2011-03-10 08:00 | 2011-03-14 17:00 | 32 | 0d |  | Subcontracted tasks | Backhoe; Joe Simmons | 48h | 2,076 |
| 34 | 3.3 | Footings |  | 3d | 2011-03-15 08:00 | 2011-03-17 17:00 | 33 | 0d |  |  |  |  |  |
| 35 | 3.4 | Install drainage |  | 3d | 2011-03-18 08:00 | 2011-03-22 17:00 | 34 | 0d |  |  | Joe Simmons | 24h | 576 |
| 36 | 3.5 | Install external utilities |  | 4d | 2011-03-23 08:00 | 2011-03-28 17:00 | 35 | 0d |  |  | Peter Jones; Susan Gianni; Fred Little; Ann Salinski; Curt Allen | 160h | 3,840 |
| 37 | 3.6 | Foundation walls |  | 4d | 2011-03-29 08:00 | 2011-04-01 17:00 | 36 | 0d |  |  |  |  |  |
| 38 | 3.7 | Lay slab foundation |  | 2d | 2011-04-04 08:00 | 2011-04-05 17:00 | 37 | 0d |  |  | Joe Simmons | 16h | 384 |
| 39 | 3.8 | Backfill |  | 2d | 2011-04-06 08:00 | 2011-04-07 17:00 | 38 | 0d |  |  |  |  |  |
| 40 | 4 | **External work** |  | 17d | 2011-04-08 08:00 | 2011-05-02 17:00 |  | 0d |  |  |  | 776h | 11,640 |
| 41 | 4.1 | Erect steel frame |  | 4d | 2011-04-08 08:00 | 2011-04-13 17:00 | 39 | 0d |  |  | David James; Jerry Davis; Laurie Macurthy | 96h | 1,440 |
| 42 | 4.2 | Erect external walls |  | 6d | 2011-04-14 08:00 | 2011-04-21 17:00 | 41 | 0d |  |  | David James; Ann Salinski; Curt Allen; Jerry Davis; Laurie Macurthy; Tim Walson | 288h | 4,320 |
| 43 | 4.3 | Install windows, external doors |  | 4d | 2011-04-22 08:00 | 2011-04-27 17:00 | 42 | 0d |  |  | David James; Laurie Macurthy; Tim Walson; Contract laborers [200%] | 160h | 2,400 |
| 44 | 4.4 | Install siding |  | 3d | 2011-04-28 08:00 | 2011-05-02 17:00 | 43 | 36.5d |  |  | Ann Salinski; Curt Allen; Jerry Davis | 72h | 1,080 |
| 45 | 4.5 | Install roof |  | 4d | 2011-04-22 08:00 | 2011-04-27 17:00 | 42 | 0d |  |  | Ann Salinski; Curt Allen; Jerry Davis; Contract laborers [200%] | 160h | 2,400 |
| 46 | 5 | **Internal work** |  | 39.5d | 2011-04-28 08:00 | 2011-06-22 12:00 |  | 0d |  |  |  | 1260h | 22,620 |
| 47 | 5.1 | Frame internal walls |  | 4d | 2011-04-28 08:00 | 2011-05-03 17:00 | 45, 43 | 0d |  |  | David James; Laurie Macurthy; Tim Walson | 96h | 1,440 |
| 48 | 5.2 | **Distribute utilities** |  | 8d | 2011-05-04 08:00 | 2011-05-13 17:00 |  | 0d |  |  |  | 484h | 9,480 |
| 49 | 5.2.1 | Distribute heating, cooling |  | 6d | 2011-05-04 08:00 | 2011-05-11 17:00 | 47 | 2d |  |  | Fred Little; Curt Allen; David James; Peter Jones [50%] | 168h | 3,600 |
| 50 | 5.2.2 | Distribute electricity, phone, cabling |  | 8d | 2011-05-04 08:00 | 2011-05-13 17:00 | 47 | 0d |  |  | David James; Jerry Davis; Ann Salinski; Susan Gianni | 256h | 4,800 |
| 51 | 5.2.3 | Distribute water, sewer |  | 3d | 2011-05-04 08:00 | 2011-05-06 17:00 | 47 | 5d |  |  | Laurie Macurthy; Tim Walson; Peter Jones [50%] | 60h | 1,080 |
| 52 | 5.3 | Insulation |  | 2d | 2011-05-16 08:00 | 2011-05-17 17:00 | 51, 50, 49 | 0d |  |  |  |  |  |
| 53 | 5.4 | Install & finish drywall |  | 4d | 2011-05-18 08:00 | 2011-05-23 17:00 | 52 | 0d |  |  | David James; Laurie Macurthy; Tim Walson | 96h | 1,440 |
| 54 | 5.5 | Paint |  | 2d | 2011-05-24 08:00 | 2011-05-25 17:00 | 53 | 0d |  |  | David James; Ann Salinski; Curt Allen | 48h | 720 |
| 55 | 5.6 | Install flooring |  | 2d | 2011-05-27 08:00 | 2011-05-30 17:00 | 54FS+1d | 0d |  |  | David James; Ann Salinski; Jerry Davis | 48h | 720 |
| 56 | 5.7 | Install trim |  | 6d | 2011-05-31 08:00 | 2011-06-07 17:00 | 55 | 0d |  |  | David James; Ann Salinski; Laurie Macurthy | 144h | 2,160 |
| 57 | 5.8 | Install built-in amenities |  | 6d | 2011-06-08 08:00 | 2011-06-15 17:00 | 56 | 0d |  |  | Susan Gianni; Peter Jones; Ann Salinski; Curt Allen; Jerry Davis | 240h | 5,040 |
| 58 | 5.9 | Install furnishings |  | 4d | 2011-06-14 13:00 | 2011-06-20 12:00 | 57FS-2.5% | 0d |  |  | Laurie Macurthy; Tim Walson; David James | 96h | 1,440 |
| 59 | 5.10 | Certificate of Occupancy |  | 2d | 2011-06-20 13:00 | 2011-06-22 12:00 | 58 | 0d |  |  | Kathy Sinclair [25%]; Pat Leary [25%] | 8h | 180 |
| 60 | 6 | Office building complete | milestone | 0d | 2011-06-22 12:00 | 2011-06-22 12:00 | 59, 44 | 0d | finish no later than 2011-07-04 18:00 |  |  |  |  |
